# eCom

Schedule from Planner, 2019-10-20 to 2020-03-11.

## Calendars

- Vorgabe: Mon-Tue off; Wed 10:00-16:00; Thu-Sun off. Exceptions (off unless hours are given): 2019-10-20 10:00-16:00, 2019-11-18.

## Resources

| Resource |
| --- |
| Robin |
| Hannes |
| Lukas |
| Hendrik |
| Danny |
| Phillip |
| Jannik |

## Schedule

| ID | WBS | Task | Type | Duration | Start | Finish | Predecessors | Complete | Constraint | Resources | Work |
| --- | --- | --- | --- | --- | --- | --- | --- | --- | --- | --- | --- |
| 1 | 1 | **Project KickOff** |  |  | 2019-10-23 | 2019-10-30 |  |  | must start on 2019-10-30 |  | 6h |
| 2 | 1.1 | Charta überarbeiten |  |  | 2019-10-23 | 2019-10-30 |  | 100% | must start on 2019-10-23 | Jannik [50%] | 6h |
| 3 | 2 | **Lastenheft** |  |  | 2019-10-23 | 2019-11-13 |  |  | must start on 2019-12-11 |  | 90h |
| 4 | 2.1 | Dokumenten Koordinierung |  |  | 2019-10-23 | 2019-10-30 |  | 100% | start no earlier than 2019-10-23 | Lukas [50%] | 6h |
| 5 | 2.2 | Artikel bestellen (Endkunde) |  |  | 2019-10-23 | 2019-10-30 |  | 100% | start no earlier than 2019-10-23 | Phillip [50%] | 6h |
| 6 | 2.3 | Artikel bei Lieferant bestellen (Shop) |  |  | 2019-10-23 | 2019-10-30 |  | 100% | start no earlier than 2019-10-23 | Phillip [34%] | 4h |
| 7 | 2.4 | Lagerverwaltung |  |  | 2019-10-23 | 2019-10-30 |  | 100% | start no earlier than 2019-10-23 | Robin [50%] | 6h |
| 8 | 2.5 | Kundenverwaltung |  |  | 2019-10-23 | 2019-10-30 |  | 100% | start no earlier than 2019-10-23 | Hannes [50%] | 6h |
| 9 | 2.6 | Lieferantenverwaltung |  |  | 2019-10-23 | 2019-10-30 |  | 100% | start no earlier than 2019-10-23 | Hannes [50%] | 6h |
| 10 | 2.7 | Rabatt/Bonusprogramm für Endkunden |  |  | 2019-10-23 | 2019-10-30 |  | 100% | start no earlier than 2019-10-23 | Phillip [34%] | 4h |
| 11 | 2.8 | Status der Bestellung (Endkunde) |  |  | 2019-10-23 | 2019-10-30 |  | 100% | start no earlier than 2019-10-23 | Phillip [34%] | 4h |
| 12 | 2.9 | Status der Lieferung an Betreiber des Shops |  |  | 2019-10-23 | 2019-10-30 |  | 100% | start no earlier than 2019-10-23 | Danny [50%] | 6h |
| 13 | 2.10 | Statistik Seite (Bestellungen, MwSt., Lagerbestände), täglich |  |  | 2019-10-23 | 2019-10-30 |  | 100% | start no earlier than 2019-10-23 | Hendrik [50%] | 6h |
| 14 | 2.11 | Einleitung, Ziel, Lieferumfang, Glosar |  |  | 2019-10-23 | 2019-10-30 |  | 100% | start no earlier than 2019-10-23 | Hendrik [50%] | 6h |
| 15 | 2.12 | Lastenheft 1. Draft | milestone | 0d | 2019-10-30 | 2019-10-30 | 14, 13, 12, 11, 10, 9, 8, 7, 6, 5, 4 |  |  |  |  |
| 16 | 2.13 | Überarbeitung |  |  | 2019-11-06 | 2019-11-13 | 15 |  |  | Hannes [50%]; Lukas [50%]; Hendrik | 18h |
| 17 | 2.14 | Produkrisiken |  |  | 2019-11-06 | 2019-11-13 | 15 |  |  | Hendrik [50%] | 6h |
| 18 | 2.15 | Angrenzungskriterien |  |  | 2019-11-06 | 2019-11-13 | 15 |  |  | Lukas [50%] | 6h |
| 19 | 3 | **Glossar** |  |  | 2019-11-06 | 2019-11-13 |  |  | must start on 2019-11-13 |  | 6h |
| 20 | 3.1 | Glossar überarbeiten |  | 1.5d | 2019-11-06 | 2019-11-13 |  |  | start no earlier than 2019-11-06 |  | 6h |
| 21 | 4 | GUI Prototyp | milestone | 0d | 2020-02-12 | 2020-02-12 |  |  | must start on 2020-02-12 |  |  |
| 22 | 5 | Storyboards | milestone | 0d | 2020-02-12 | 2020-02-12 |  |  | must start on 2020-02-12 |  |  |
| 23 | 6 | Risikoanalyse | milestone | 0d | 2020-02-12 | 2020-02-12 |  |  | must start on 2020-02-12 |  |  |
| 24 | 7 | Projektplan | milestone | 0d | 2020-02-12 | 2020-02-12 |  |  | must start on 2020-02-12 |  |  |

| ID | WBS | Task | Type | Duration | Start | Finish | Predecessors | Complete | Constraint | Resources | Work |
| --- | --- | --- | --- | --- | --- | --- | --- | --- | --- | --- | --- |
| 25 | 8 | **Pflichtenheft** |  |  | 2019-11-06 | 2019-11-13 |  |  | must start on 2020-03-11 |  | 12h |
| 26 | 8.1 | Vorbereiten |  |  | 2019-11-06 | 2019-11-13 | 15 |  |  | Hannes | 12h |
| 27 | 9 | Mastertestplan | milestone | 0d | 2020-03-11 | 2020-03-11 |  |  | must start on 2020-03-11 |  |  |
| 28 | 10 | Systemtests | milestone | 0d | 2020-03-11 | 2020-03-11 |  |  | must start on 2020-03-11 |  |  |
| 29 | 11 | **Orga** |  |  | 2019-10-20 | 2019-10-30 |  |  |  |  | 12h |
| 30 | 11.1 | Infrastruktur und Wiki einrichten |  |  | 2019-10-20 | 2019-10-20 |  | 100% | must start on 2019-10-16 | Hendrik | 6h |
| 31 | 11.2 | Templates anlegen für Google Doc |  | 2d | 2019-10-20 | 2019-10-30 |  | 100% |  | Robin [38%] | 6h |
